# openCMISS

Schedule from GanttProject, 2005-12-21 to 2006-03-30.
Bioengineering Institute, University of Auckland
The CMISS development plan

## Calendars

- Project calendar: Mon-Fri working; Sat-Sun off.

## Resources

| Resource |
| --- |
| Carey Stevens |
| Andrew MIllar |
| Shane Blackett |
| Karl Tomlinson |
| Poul Neilsen |
| David Nickerson |
| Travis Austen |
| Greg Sands |

## Schedule

| ID | WBS | Task | Duration | Start | Finish | Predecessors | Complete | Resources |
| --- | --- | --- | --- | --- | --- | --- | --- | --- |
| 1 | 1 | **openCMISS** | 72d | 2005-12-21 | 2006-03-30 |  | 9% |  |
| 2 | 1.1 | Data Structures | 72d | 2005-12-21 | 2006-03-30 |  | 5% | Karl Tomlinson; Greg Sands; Shane Blackett; Poul Neilsen; Travis Austen |
| 3 | 1.2 | **mozCmgui** | 38d | 2005-12-21 | 2006-02-10 |  | 19% |  |
| 4 | 1.2.1 | MS Windows port | 18d | 2005-12-21 | 2006-01-13 |  | 40% |  |
| 5 | 1.2.2 | Migrate demos | 18d | 2005-12-21 | 2006-01-13 |  |  | Carey Stevens |
| 6 | 1.2.3 | **Documentation** | 38d | 2005-12-21 | 2006-02-10 |  | 18% |  |
| 7 | 1.2.3.1 | Build instructions | 18d | 2005-12-21 | 2006-01-13 |  | 40% | Andrew MIllar; Carey Stevens [10%] |
| 8 | 1.2.3.2 | Install instructions | 10d | 2006-01-02 | 2006-01-13 |  |  | Andrew MIllar; Carey Stevens |
| 9 | 1.2.3.3 | Developer Guide | 10d | 2006-01-16 | 2006-01-27 | 8 |  | Carey Stevens |
| 10 | 1.2.3.4 | Roadmap | 10d | 2006-01-30 | 2006-02-10 | 9 |  | Andrew MIllar; Carey Stevens |
